# JUN

Schedule from MS Project, 2006-05-04 to 2006-07-31, status date 2006-06-22, A marks actual dates.
譛ｬ遉ｾ繧ｷ繧ｹ繝�繝髢狗匱驛ｨ

## Calendars

- 標準: Mon-Fri 10:00-18:00; Sat-Sun off. Exceptions (off unless hours are given): 2006-05-04 to 2006-05-05 13:00-18:00, 2006-05-08 to 2006-05-12 13:00-18:00, 2006-05-15 to 2006-05-19 13:00-18:00, 2006-05-22 to 2006-05-26 13:00-18:00, 2006-05-29 to 2006-06-02 13:00-18:00, 2006-06-05 to 2006-06-09 13:00-18:00, 2006-06-12 to 2006-06-14 13:00-18:00, 2006-07-01 to 2006-07-02 08:00-12:00, 13:00-17:00, 2006-07-08 to 2006-07-09 08:00-12:00, 13:00-17:00, 2006-07-15 to 2006-07-16 08:00-12:00, 13:00-17:00.

## Resources

| Resource |
| --- |
| 全員 |
| 渡辺 |
| 嶋村 |
| 水島 |
| 学生 |
| 重松先生 |

## Schedule

| ID | WBS | Task | Type | Duration | Start | Finish | Predecessors | Complete | Total slack | Constraint | Resources | Work | Actual work |
| --- | --- | --- | --- | --- | --- | --- | --- | --- | --- | --- | --- | --- | --- |
| 1 | 1 | **要求分析** |  | 9.88d? | 2006-05-04 A | 2006-05-25 A |  | 100% |  |  |  | 79h | 79h |
| 2 | 1.1 | 要求分析 |  | 9.88d? | 2006-05-04 A | 2006-05-25 A |  | 100% |  | finish no earlier than 2006-05-25 | 全員 | 79h | 79h |
| 3 | 2 | **基本設計** |  | 3d? | 2006-05-26 A | 2006-06-01 A | 1 | 100% |  |  |  | 72h | 72h |
| 4 | 2.1 | DB定義書（ER図） |  | 3d? | 2006-05-26 A | 2006-06-01 A |  | 100% |  | start no earlier than 2006-05-26 | 渡辺 | 24h | 24h |
| 5 | 2.2 | 画面定義書 |  | 3d? | 2006-05-26 A | 2006-06-01 A |  | 100% |  | start no earlier than 2006-05-26 | 嶋村 | 24h | 24h |
| 6 | 2.3 | 画面遷移図 |  | 3d? | 2006-05-26 A | 2006-06-01 A |  | 100% |  | start no earlier than 2006-05-26 | 水島 | 24h | 24h |
| 7 | 3 | 中間発表 | milestone | 0.5d? | 2006-06-01 A | 2006-06-01 A |  | 100% |  | finish no earlier than 2006-06-01 |  |  |  |
| 8 | 4 | **詳細設計** |  | 3.62d? | 2006-06-02 A | 2006-06-09 A | 3 | 100% |  |  |  | 29h | 29h |
| 9 | 4.1 | 処理機能記述書 |  | 3.62d? | 2006-06-02 A | 2006-06-09 A |  | 100% |  | finish no earlier than 2006-06-08 | 全員 | 29h | 29h |
| 10 | 5 | **プロトタイプ一回目実装** |  | 26.75d? | 2006-06-06 A | 2006-07-11 A | 8 | 100% |  |  |  | 38h | 38h |
| 11 | 5.1 | 開発・単体テスト |  | 6.75d? | 2006-06-06 A | 2006-06-19 A |  | 100% |  | start no earlier than 2006-06-09 |  |  |  |
| 12 | 5.2 | 結合テスト |  | 1.88d? | 2006-06-19 A | 2006-06-20 A |  | 100% |  | start no earlier than 2006-06-19 |  |  |  |
| 13 | 5.3 | レビュー | milestone | 0.88d? | 2006-06-22 A | 2006-06-22 A |  | 100% |  | finish no earlier than 2006-06-22 |  |  |  |
| 14 | 5.4 | ユーザーレビュー（重松先生） |  | 0.88d? | 2006-06-23 A | 2006-06-23 A | 13 | 100% |  | start no earlier than 2006-06-23 |  |  |  |
| 15 | 5.5 | レビュー後修正作業 |  | 4.88d? | 2006-06-26 A | 2006-06-30 A | 14 | 100% |  | finish no earlier than 2006-06-30 |  |  |  |
| 16 | 5.6 | マニュアル作成 |  | 3.88d? | 2006-07-04 A | 2006-07-07 A | 15 | 100% |  | start no earlier than 2006-07-04 | 嶋村 | 31h | 31h |
| 17 | 5.7 | アンケート作成 |  | 0.88d? | 2006-07-07 A | 2006-07-07 A |  | 100% |  | finish no earlier than 2006-07-07 | 水島 | 7h | 7h |
| 18 | 5.8 | ユーザー（学生）検証 |  | 1d? | 2006-07-08 A | 2006-07-08 A | 17 | 100% |  | finish no earlier than 2006-07-08 |  |  |  |
| 19 | 5.9 | ユーザー（重松先生）検証（添削作業） |  | 1d? | 2006-07-09 A | 2006-07-09 A |  | 100% |  | start no earlier than 2006-07-09 |  |  |  |
| 20 | 5.10 | レビュー後修正作業 |  | 1.88d? | 2006-07-10 A | 2006-07-11 A | 19 | 100% |  | finish no earlier than 2006-07-16 |  |  |  |
| 21 | 6 | **ユーザー検証** |  | 8.88d? | 2006-07-14 A | 2006-07-24 A | 10 | 100% |  |  |  |  |  |
| 22 | 6.1 | ユーザー（学生）検証 |  | 0.88d? | 2006-07-14 A | 2006-07-14 A | 20 | 100% |  | finish no earlier than 2006-07-19 |  |  |  |
| 23 | 6.2 | ユーザー検証（重松先生）検証 |  | 7.88d? | 2006-07-15 A | 2006-07-24 A | 22 | 100% |  | start no earlier than 2006-07-20 |  |  |  |
| 24 | 7 | **最終発表準備** |  | 16d? | 2006-07-11 A | 2006-07-30 A |  | 100% |  |  |  | 128h | 128h |
| 25 | 7.1 | 最終発表準備（資料作成） |  | 16d? | 2006-07-11 A | 2006-07-30 A |  | 100% |  | finish no earlier than 2006-07-27 | 全員 | 128h | 128h |
| 26 | 8 | 最終発表 | milestone | 0.5d? | 2006-07-31 | 2006-07-31 |  |  | 0d | finish no earlier than 2006-07-31 |  |  |  |
